# SUMINISTRO DE ROCA PARA EL SUB-PROYECTO A2-1 Y A2-2 PUESTO EN ACOPIO

Schedule from Primavera P6, 2025-02-20 to 2025-06-24, data date 2025-02-20, costs in PEN.

## Calendars

- Calendario Obra: Mon-Sun 08:00-16:00.

## Resources

| Resource | Group | Rate |
| --- | --- | --- |
| Resources -incentivado | material | 1 |

## Schedule

| ID | WBS | Activity | Type | Duration | Start | Finish | Predecessors | Total float | Free float | Resources | Cost |
| --- | --- | --- | --- | --- | --- | --- | --- | --- | --- | --- | --- |
| A1000 |  | CARTA DE ADJUDICACIÓN (LOA) / KOM | milestone | 0d | 2025-02-20 | 2025-02-20 |  | 0d |  |  |  |
|  | 1 | **MOVILIZACIÓN DEL SUBCONTRATISTA** |  |  | 2025-02-20 | 2025-02-23 |  |  |  |  |  |
| A1010 |  | PRESENTACIÓN DE CAMOS A MÉDICO OCUPACIONAL |  | 1d | 2025-02-20 | 2025-02-20 | A1000 SS | 0d |  | Resources -incentivado [24] | 28,281.22 |
| A1020 |  | PRESENTACIÓN DE DOCUMENTACIÓN DE PERSONAL |  | 1d | 2025-02-21 | 2025-02-21 | A1010 | 0d |  | Resources -incentivado [24] | 21,210.92 |
| A1030 |  | HOMOLOGACIÓN DE EQUIPOS |  | 1d | 2025-02-22 | 2025-02-22 | A1020 | 0d |  | Resources -incentivado [16] | 21,210.92 |
| A1040 |  | INDUCCIÓN DE PERSONAL |  | 1d | 2025-02-23 | 2025-02-23 | A1030 | 121d |  | Resources -incentivado [16] | 14,140.61 |
| A1090 |  | MOVILIZACIÓN DE EQUIPOS |  | 1d | 2025-02-23 | 2025-02-23 | A1030 | 0d |  | Resources -incentivado [16] | 664,608.78 |
|  | 2 | **ROCA EN DIQUES** |  |  | 2025-02-24 | 2025-06-23 |  |  |  |  |  |
|  | 1 | **SUBPROYECTO A3** |  |  | 2025-02-24 | 2025-06-23 |  |  |  |  |  |
| A1100 |  | DIQUE A3-D-01 |  | 17d | 2025-02-24 | 2025-03-12 | A1090 | 0d |  | Resources -incentivado [136] | 1,414,061.24 |
| A1120 |  | DIQUE A3-I-01 |  | 17d | 2025-02-24 | 2025-03-12 | A1090 | 1d | 0d | Resources -incentivado [136] | 1,414,061.24 |
| A1110 |  | DIQUE A3-D-02 |  | 103d | 2025-03-13 | 2025-06-23 | A1100 | 0d |  | Resources -incentivado [824] | 5,656,244.95 |
| A1130 |  | DIQUE A3-I-02 |  | 20d | 2025-03-13 | 2025-04-01 | A1120 | 1d | 0d | Resources -incentivado [160] | 1,414,061.24 |
| A1140 |  | DIQUE A3-I-03 |  | 83d | 2025-04-02 | 2025-06-23 | A1130, A1120 | 1d |  | Resources -incentivado [664] | 2,828,122.48 |
|  | 3 | **ACTIVIDADES DE DESMOVILIZACIÓN** |  |  | 2025-06-24 | 2025-06-24 |  |  |  |  |  |
| A1070 |  | DESMOVILIZACIÓN DE EQUIPOS |  | 1d | 2025-06-24 | 2025-06-24 | A1110 | 0d |  | Resources -incentivado [40] | 664,608.78 |
| A1080 |  | FIN DE PROYECTO | milestone | 0d | 2025-06-24 | 2025-06-24 | A1070 FF | 0d |  |  |  |
